# 2008 Feb and March Hall C work Rev.3

Schedule from MS Project, 2008-02-12 to 2008-04-04.
Jefferson Lab

## Calendars

- Standard: Mon-Fri 08:00-12:00, 13:00-17:00; Sat-Sun off.

## Resources

| Resource |
| --- |
| RADCON |
| Alignment Group |
| Hall-C tech's |
| ACC tech's |
| Hall C Tech's |
| Cryo Target Tech's |
| Hall C Tech's / ESH&Q |
| Experimenters |
| Hall C Tech's / RADCO |
| Hall C Tech's / RADCON |
| Hall C Tech's / Experim. |
| Target Group / Experimenters |
| Target Group / Experim. |

## Schedule

| ID | WBS | Task | Duration | Start | Finish | Total slack | Free slack | Constraint | Deadline | Resources | Work | Text1 | Text5 | Text7 | Text12 | Text13 | Text8 | Text11 | Text2 | Text3 |
| --- | --- | --- | --- | --- | --- | --- | --- | --- | --- | --- | --- | --- | --- | --- | --- | --- | --- | --- | --- | --- |
| 1 | 1 | Hall C work for February and March 2008 | 36d | 2008-02-12 | 2008-04-01 | 3d |  | finish no earlier than 2008-04-01 |  |  |  |  |  |  |  |  |  |  |  |  |
| 3 | 2 | Disconnect and move BIG BITE magnet to Hall A. | 1d? | 2008-02-13 | 2008-02-13 | -1d | 0d | finish no earlier than 2008-02-13 | 2008-02-12 | Hall C Tech's | 8h | C-08-013-T | lift plan | 2 | C-08-007-L | Complete |  |  |  |  |
| 4 | 3 | RADCON support required | 1d? | 2008-02-12 | 2008-02-12 | 35d |  | start no earlier than 2008-02-12 |  | RADCON | 8h |  |  | 0 |  | Complete |  |  |  |  |
| 5 | 4 | Move BIG BITE stand and base plate to bone yard. | 2d? | 2008-02-13 | 2008-02-14 | 33d |  | finish no earlier than 2008-02-14 |  | Hall C Tech's | 16h |  |  | 0 |  | Complete |  |  |  |  |
| 6 | 5 | RADCON support required | 2d? | 2008-02-13 | 2008-02-14 | 33d |  | finish no earlier than 2008-02-14 |  | RADCON | 16h |  |  | 0 |  | Complete |  |  |  |  |
| 7 | 6 | Move HES magnet boxes from the Test Lab to Hall C and unpack. | 3d? | 2008-02-14 | 2008-02-18 | 31d |  | start no earlier than 2008-02-14 |  | Hall C Tech's | 24h |  | lift plan | 1 | C-08-008-L | Complete |  |  |  |  |
| 8 | 7 | Move all HES boxes from the storage building to Hall C and unpack | 3d? | 2008-02-18 | 2008-02-20 | 29d |  | finish no earlier than 2008-02-20 |  | Hall C Tech's | 24h |  |  | 0 |  | Complete |  |  |  |  |
| 9 | 8 | Preassemble magnets, label parts and store. | 3d? | 2008-02-21 | 2008-02-25 | 26d |  | finish no earlier than 2008-02-25 |  | Hall C Tech's | 24h |  |  | 1 |  | Delayed |  |  |  |  |
| 10 | 9 | Strip G-0 FW and disassemble 10 detectors. | 15d? | 2008-02-21 | 2008-03-12 | 17d |  | finish no earlier than 2008-03-12 |  | Hall C Tech's | 120h | C-08-017-T |  | 1 | C-08-010-L | Active |  |  |  |  |
| 11 | 10 | Pack and remove all parts from Hall C | 2d? | 2008-03-03 | 2008-03-04 | 20d |  | finish no earlier than 2008-03-04 |  | Hall C Tech's | 16h |  |  | 0 |  | Active |  |  |  |  |
| 12 | 11 | Remove blue SOS magnet from pivot and move to the physics storage Bld. | 2d? | 2008-02-26 | 2008-02-27 | 27d |  | finish no earlier than 2008-02-27 |  | Hall C Tech's | 16h | C-08-001-T | lift plan | 2 |  | Complete |  |  |  |  |
| 13 | 12 | RADCON support required | 2d? | 2008-02-26 | 2008-02-27 | 27d |  | finish no earlier than 2008-02-27 |  | RADCON | 16h |  |  | 0 |  | Complete |  |  |  |  |
| 14 | 13 | Fabricate and weld covers onto rails in prep. for concrete pad extension. | 6d? | 2008-03-04 | 2008-03-11 | 15d |  | finish no earlier than 2008-03-11 |  | Hall C Tech's | 48h |  |  | 0 |  | Delayed | Yes |  |  |  |
| 15 | 14 | RADCON support required | 4d? | 2008-03-04 | 2008-03-07 | 17d |  | finish no earlier than 2008-03-07 |  | RADCON | 32h |  |  | 0 |  | Delayed |  |  |  |  |
| 16 | 15 | Remove 24” gate valve on the downstream side | 1d? | 2008-03-04 | 2008-03-04 | 20d |  | start no earlier than 2008-03-04 |  | Hall C Tech's | 8h | C-08-003-T |  | 1 |  | Active |  |  |  |  |
| 17 | 16 | RADCON support required | 4d? | 2008-03-04 | 2008-03-07 | 17d |  | finish no earlier than 2008-03-07 |  | RADCON | 32h |  |  | 0 |  | Active |  |  |  |  |
| 18 | 17 | Rmove absorber plates from BIG CAL | 1d? | 2008-03-05 | 2008-03-05 | 22d |  | start no earlier than 2008-03-05 |  | Hall C Tech's | 8h | C-09-008-T |  | 1 | C-08-006-L |  |  |  |  |  |
| 19 | 18 | Unbolt and crane out G-0 SMS upstream end cap. | 1d? | 2008-03-06 | 2008-03-06 | 21d |  | start no earlier than 2008-03-06 |  | Hall C Tech's | 8h |  | lift plan | 2 | Lift plan | Delayed |  |  |  |  |
| 20 | 19 | Remove lead blocks from end cap and bring to lead storage Bld. | 2d? | 2008-03-07 | 2008-03-10 | 19d |  | finish no earlier than 2008-03-10 |  | Hall C Tech's | 16h | Yes |  | 1 |  | Delayed |  |  |  |  |
| 21 | 20 | Unbolt and lift out down stream end cap | 1d? | 2008-03-11 | 2008-03-11 | 18d |  | start no earlier than 2008-03-11 |  | Hall C Tech's | 8h |  |  | 2 | Lift plan | Delayed |  |  |  |  |
| 22 | 21 | Bolt both end caps together, seal for storage | 1d? | 2008-03-12 | 2008-03-12 | 17d |  | start no earlier than 2008-03-12 |  | Hall C Tech's | 8h |  |  | 0 |  | Delayed |  |  |  |  |
| 23 | 22 | Change HMS actuators. General HMS maintenance | 4d? | 2008-03-18 | 2008-03-21 | 10d |  | finish no earlier than 2008-03-21 |  | Hall C Tech's | 32h |  |  | 0 |  | Delayed |  | Yes |  |  |
| 24 | 23 | Remove GEP beam line spool piece, leak check old window | 2d? | 2008-03-12 | 2008-03-13 | 16d |  | finish no earlier than 2008-03-13 |  | Hall C Tech's / RADCON | 16h | Yes |  | 2 | RWP |  |  |  | 7225 |  |
| 25 | 24 | RADCON support required | 2d? | 2008-03-12 | 2008-03-13 | 16d |  | finish no earlier than 2008-03-13 |  | RADCON | 16h |  |  | 0 | RWP |  |  |  |  |  |
| 26 | 25 | Change Berilium window and leak check | 3d? | 2008-03-14 | 2008-03-18 | 13d |  | finish no earlier than 2008-03-18 |  | Hall C Tech's / ESH&Q | 24h | Yes |  | 1 | RWP |  |  |  |  |  |
| 27 | 26 | RADCON support required | 3d? | 2008-03-14 | 2008-03-18 | 13d |  | finish no earlier than 2008-03-18 |  | RADCON | 24h |  |  | 0 | RWP |  |  |  |  |  |
| 28 | 27 | Fabricate parts to modify beam dump connecting section and install | 11d? | 2008-03-05 | 2008-03-19 | 12d |  | finish no earlier than 2008-03-19 |  | Hall C Tech's / RADCON | 88h |  |  | 1 | RWP | Delayed |  | Yes |  |  |
| 29 | 28 | RADCON support required | 3d? | 2008-03-14 | 2008-03-18 | 13d |  | finish no earlier than 2008-03-18 |  | RADCON | 24h |  |  | 0 | RWP | Delayed |  |  |  |  |
| 30 | 29 | Reinstall beam line spool piece and leak test beam pipe | 1d? | 2008-03-19 | 2008-03-19 | 12d |  | start no earlier than 2008-03-19 |  | Hall C Tech's / RADCON | 8h | Yes |  | 1 | RWP |  |  |  |  |  |
| 31 | 30 | RADCON support required | 1d? | 2008-03-19 | 2008-03-19 | 12d |  | finish no earlier than 2008-03-19 |  | RADCON | 8h |  |  | 0 | RWP |  |  |  |  |  |
| 32 | 31 | Pump out Moller cryo lines | 1d? | 2008-03-25 | 2008-03-25 | 8d |  | start no earlier than 2008-03-25 |  | Hall C Tech's | 8h |  |  | 1 |  |  |  | Yes |  |  |
| 33 | 32 | Crane BIG CAL into position | 1d? | 2008-03-26 | 2008-03-26 | 4d |  | start no earlier than 2008-03-26 |  | Hall C Tech's / Experim. | 8h |  |  | 1 | C-08-005-L |  |  |  |  |  |
| 37 | 33 | Cryo Target work on Pivot | 27d? | 2008-02-25 | 2008-04-01 | 3d |  | finish no earlier than 2008-04-01 |  |  |  |  |  |  | SOP |  |  |  | 7229 | Yes |
| 38 | 34 | Unbolt and remove scattering chamber windows | 1d? | 2008-03-03 | 2008-03-03 | 21d |  | finish no earlier than 2008-03-03 |  | Cryo Target Tech's | 8h | Yes |  | 1 |  | Complete |  |  |  |  |
| 39 | 35 | RADCON support required | 1d? | 2008-03-03 | 2008-03-03 | 24d |  | start no earlier than 2008-03-03 |  | RADCON | 8h |  |  | 0 |  | Complete |  |  |  |  |
| 40 | 36 | Reconfigure the target cells and blocks for GeP in April. | 1d? | 2008-03-05 | 2008-03-05 | 19d |  | finish no earlier than 2008-03-05 |  | Cryo Target Tech's | 8h | Yes |  | 1 |  | Active |  |  |  |  |
| 41 | 37 | RADCON support required | 1d? | 2008-03-05 | 2008-03-05 | 19d |  | start no earlier than 2008-03-05 |  | RADCON | 8h |  |  | 0 |  | Active |  |  |  |  |
| 42 | 38 | Align target cells | 1d? | 2008-03-10 | 2008-03-10 | 16d |  | finish no earlier than 2008-03-10 |  | Alignment Group | 8h | Yes |  | 1 |  |  |  |  | Yes |  |
| 43 | 39 | install new window o-rings | 1d? | 2008-03-12 | 2008-03-12 | 14d |  | finish no earlier than 2008-03-12 |  | Hall C Tech's | 8h |  |  | 0 |  |  |  |  |  |  |
| 44 | 40 | Bolt on windows | 1d? | 2008-03-12 | 2008-03-12 | 14d |  | finish no earlier than 2008-03-12 |  | Hall C Tech's | 8h | Yes |  | 1 |  |  |  |  |  |  |
| 45 | 41 | Leak test scattering chamber and target cells | 1d? | 2008-03-17 | 2008-03-17 | 11d |  | start no earlier than 2008-03-17 |  | Cryo Target Tech's | 8h | Yes |  | 2 |  |  |  | Yes |  |  |
| 46 | 42 | Vent scattering chamber | 1d? | 2008-03-18 | 2008-03-18 | 10d |  | start no earlier than 2008-03-18 |  | Cryo Target Tech's | 8h |  |  | 1 |  |  |  |  |  |  |
| 47 | 43 | Pump out target chamber and cool down for beam | 3d? | 2008-03-28 | 2008-04-01 | 3d |  | finish no earlier than 2008-04-01 |  | Target Group / Experim. | 24h |  |  | 2 | Targ ops manu |  |  |  |  |  |
| 50 | 44 | Test installation for SANE Cherenkov counter and tracker | 12d? | 2008-03-17 | 2008-04-01 | 3d |  | start no earlier than 2008-03-17 |  |  |  |  |  |  |  |  |  |  |  |  |
| 51 | 45 | Remove pivot railing and platform extensions | 1d? | 2008-03-17 | 2008-03-17 | 14d |  | start no earlier than 2008-03-17 |  | Hall C Tech's | 8h | Yes |  | 1 |  |  |  |  |  |  |
| 52 | 46 | Install Cherenkov detector support frame, align and bolt to floor | 1d? | 2008-03-17 | 2008-03-17 | 14d |  | start no earlier than 2008-03-17 |  | Hall C Tech's | 8h |  |  | 0 |  |  |  |  |  |  |
| 53 | 47 | Install railing and staircase then secure staircase to platform | 1d? | 2008-03-17 | 2008-03-17 | 14d |  | start no earlier than 2008-03-17 |  | Hall C Tech's | 8h | Yes |  | 1 |  |  |  |  |  |  |
| 54 | 48 | Place Cherenkov on stand, about 10 cm back from SANE position | 1d? | 2008-03-18 | 2008-03-18 | 13d |  | start no earlier than 2008-03-18 |  | Hall C Tech's | 8h |  |  | 0 |  |  |  |  |  |  |
| 55 | 49 | Connect HV and signal cables to Cherenkov | 1d? | 2008-03-19 | 2008-03-19 | 12d |  | start no earlier than 2008-03-19 |  | Experimenters | 8h |  |  | 0 |  |  |  |  |  |  |
| 56 | 50 | Hook up gas flow system to Cherenkov | 1d? | 2008-03-20 | 2008-03-20 | 11d |  | start no earlier than 2008-03-20 |  | Hall C Tech's | 8h |  |  | 0 |  |  |  |  |  |  |
| 57 | 51 | Install SANE tracker between Cherenkov and target | 1d? | 2008-03-19 | 2008-03-19 | 12d |  | start no earlier than 2008-03-19 |  | Hall C Tech's | 8h | Yes |  | 1 |  |  |  |  |  |  |
| 58 | 52 | Install a few SANE Lucite counters, connect HV and signal cables | 1d? | 2008-03-19 | 2008-03-19 | 12d |  | start no earlier than 2008-03-19 |  | Hall C Tech's / Experim. | 8h | Yes |  | 1 |  |  |  |  |  |  |
| 59 | 53 | Install new support stand for shielding, bolt to floor | 1d? | 2008-03-20 | 2008-03-20 | 11d |  | start no earlier than 2008-03-20 |  | Hall C Tech's | 8h | Yes |  | 0 |  |  |  |  |  |  |
| 60 | 54 | Weld bracket to Pivot and bolt down girder | 1d? | 2008-03-20 | 2008-03-20 | 11d |  | start no earlier than 2008-03-20 |  | Hall C Tech's | 8h |  |  | 0 |  |  | Yes |  |  |  |
| 61 | 55 | RADCON support required | 1d? | 2008-03-20 | 2008-03-20 | 11d |  | start no earlier than 2008-03-20 |  | RADCON | 8h |  |  | 0 |  |  |  |  | Yes |  |
| 62 | 56 | Fill 3 ALU boxes with painted lead bricks, crane onto girder and bolt down | 2d? | 2008-03-21 | 2008-03-24 | 9d |  | finish no earlier than 2008-03-24 |  | Hall C Tech's / ESH&Q | 16h |  | TOSP | 1 | TOSP |  |  |  | Yes |  |
| 63 | 57 | Crane in and place align 3 ALU shield boxes onto Pivot | 2d? | 2008-03-25 | 2008-03-26 | 7d |  | finish no earlier than 2008-03-26 |  | Hall C Tech's | 16h | Yes |  | 1 |  |  |  |  |  |  |
| 64 | 58 | Place mounting angle brackets and weld to Pivot | 1d? | 2008-03-26 | 2008-03-26 | 7d |  | start no earlier than 2008-03-26 |  | Hall C Tech's | 8h | Yes |  | 1 |  |  | Yes |  |  |  |
| 65 | 59 | RADCON support required | 1d? | 2008-03-26 | 2008-03-26 | 7d |  | start no earlier than 2008-03-26 |  | RADCON | 8h |  |  | 0 |  |  |  |  | Yes |  |
| 66 | 60 | Fill boxes with lead painted bricks, crane onto Pivot and bolt down | 2d? | 2008-03-27 | 2008-03-28 | 5d |  | finish no earlier than 2008-03-28 |  | Hall C Tech's / ESH&Q | 16h |  | TOSP | 1 | TOSP |  |  |  |  |  |
| 67 | 61 | Remove aerial lifts and equipment, cleanup Hall and lock up | 1d? | 2008-03-31 | 2008-03-31 | 4d |  | start no earlier than 2008-03-31 |  | Hall C Tech's | 8h |  |  | 0 |  |  |  |  |  |  |
| 68 | 62 | BEAM, SANE test run | 4d? | 2008-04-01 | 2008-04-04 | 0d |  | finish no earlier than 2008-04-04 |  | Experimenters | 32h |  |  | 1 | Beam permit |  |  |  |  |  |
| 69 | 63 | Disconnect and remove Cherenkov detector and tracker | 1d? | 2008-04-04 | 2008-04-04 | 0d |  | finish no earlier than 2008-04-04 |  | Hall C Tech's | 8h | Yes |  | 0 |  |  |  |  |  |  |
| 70 | 64 | RADCON support required | 1d? | 2008-04-04 | 2008-04-04 | 0d |  | start no earlier than 2008-04-04 |  | RADCON | 8h |  |  | 0 |  |  |  |  | Yes |  |
| 71 | 65 | Unbolt and crane 3 lead shielding boxes of Pivot | 1d? | 2008-04-04 | 2008-04-04 | 0d |  | start no earlier than 2008-04-04 |  | Hall C Tech's | 8h | Yes |  | 1 |  |  |  |  |  |  |
| 72 | 66 | RADCON support required | 1d? | 2008-04-04 | 2008-04-04 | 0d |  | start no earlier than 2008-04-04 |  | RADCON | 8h |  |  | 0 |  |  |  |  |  |  |
| 73 | 67 | Unbolt and crane 3 lead shielding boxes of Girder and store | 1d? | 2008-04-04 | 2008-04-04 | 0d |  | start no earlier than 2008-04-04 |  | Hall C Tech's | 8h | Yes |  | 1 |  |  |  |  |  |  |
| 74 | 68 | RADCON support required | 1d? | 2008-04-04 | 2008-04-04 | 0d |  | start no earlier than 2008-04-04 |  | RADCON | 8h |  |  | 0 |  |  |  |  |  |  |
| 75 | 69 | Remove railing and staircase from Cherenkove stand | 1d? | 2008-04-04 | 2008-04-04 | 0d |  | start no earlier than 2008-04-04 |  | Hall C Tech's | 8h | Yes |  | 1 |  |  |  |  |  |  |
